Schedule from MS Project, 2023-01-28 to 2024-08-19, status date 2023-01-28.

## Calendars

- Standard: Mon-Sun 08:00-12:00, 13:00-17:00.

## Schedule

| ID | WBS | Task | Type | Duration | Start | Finish | Predecessors | Baseline start | Baseline finish | Baseline duration | Baseline 1 start | Baseline 1 finish | Total slack | Free slack | Start Date | Finish Date | شروع | پایان |
| --- | --- | --- | --- | --- | --- | --- | --- | --- | --- | --- | --- | --- | --- | --- | --- | --- | --- | --- |
| 1 | 1 | **Reciprocating Compressor** |  | 570d | 2023-01-28 | 2024-08-19 |  | 2021-05-25 | 2022-06-05 | 377d | 2021-05-25 | 2022-06-05 | 0d |  | 100/8/23 | 103/5/29 | 1401/11/8 | 1403/5/29 |
| 2 | 1.1 | **Milestone** |  | 570d | 2023-01-28 | 2024-08-19 |  | 2021-05-25 | 2022-06-05 | 377d | 2021-05-25 | 2022-06-05 | 0d |  | 100/8/23 | 103/5/29 | 1401/11/8 | 1403/5/29 |
| 3 | 1.1.1 | Start | milestone | 0d | 2023-01-28 | 2023-01-28 |  | 2021-05-25 | 2021-05-25 | 0d | 2021-05-25 | 2021-05-25 | 570d |  | 101/11/8 | 101/11/8 | 1401/11/8 | 1401/11/8 |
| 4 | 1.1.2 | Advance Payment | milestone | 0d | 2023-01-28 | 2023-01-28 |  |  |  |  |  |  | 0d |  | 101/11/8 | 101/11/8 | 1401/11/8 | 1401/11/8 |
| 5 | 1.1.3 | Finish | milestone | 0d | 2024-08-19 | 2024-08-19 | 101 | 2022-06-05 | 2022-06-05 | 0d | 2022-06-05 | 2022-06-05 | 0d |  | 103/5/29 | 103/5/29 | 1403/5/29 | 1403/5/29 |
| 6 | 1.2 | **Engineering** |  | 320d | 2023-01-28 | 2023-12-13 |  | 2021-06-02 | 2022-06-05 | 369d | 2021-06-02 | 2022-06-05 | 250d |  | 100/8/23 | 102/9/22 | 1401/11/8 | 1402/9/22 |
| 7 | 1.2.1 | Civil |  | 320d | 2023-01-28 | 2023-12-13 | 4 | 2021-06-02 | 2021-06-08 | 7d | 2021-06-02 | 2021-06-08 | 250d | 0d | 101/11/8 | 102/9/22 | 1401/11/8 | 1402/9/22 |
| 8 | 1.2.2 | Piping |  | 320d | 2023-01-28 | 2023-12-13 | 7SS |  |  |  |  |  | 250d | 0d | 101/11/8 | 102/9/22 | 1401/11/8 | 1402/9/22 |
| 9 | 1.2.3 | Electrical |  | 320d | 2023-01-28 | 2023-12-13 | 8SS |  |  |  |  |  | 250d | 0d | 101/11/8 | 102/9/22 | 1401/11/8 | 1402/9/22 |
| 10 | 1.2.4 | Mechanic |  | 320d | 2023-01-28 | 2023-12-13 | 9SS |  |  |  |  |  | 250d | 0d | 101/11/8 | 102/9/22 | 1401/11/8 | 1402/9/22 |
| 11 | 1.2.5 | Instruments |  | 320d | 2023-01-28 | 2023-12-13 | 10SS |  |  |  |  |  | 250d |  | 101/11/8 | 102/9/22 | 1401/11/8 | 1402/9/22 |
| 12 | 1.3 | **SUPPLY/CONSTRUCTION** |  | 330d | 2023-03-01 | 2024-01-24 |  | 2021-09-01 | 2021-11-04 | 65d | 2021-09-01 | 2022-04-14 | 0d |  | 100/8/23 | 102/11/4 | 1401/12/10 | 1402/11/4 |
| 13 | 1.3.1 | **Bare Block** |  | 330d | 2023-03-01 | 2024-01-24 |  | 2021-09-01 | 2021-09-25 | 25d | 2021-09-01 | 2021-09-25 | 0d |  | 100/8/30 | 102/11/4 | 1401/12/10 | 1402/11/4 |
| 14 | 1.3.1.1 | Crank Case |  | 30d | 2023-03-01 | 2023-03-30 | 4FS+32d | 2021-09-01 | 2021-09-25 | 25d | 2021-09-01 | 2021-09-25 | 0d |  | 101/12/10 | 102/1/10 | 1401/12/10 | 1402/1/10 |
| 15 | 1.3.1.2 | Crank Shaft |  | 30d | 2023-03-31 | 2023-04-29 | 14 |  |  |  |  |  | 0d |  | 102/1/11 | 102/2/9 | 1402/1/11 | 1402/2/9 |
| 16 | 1.3.1.3 | Connecting Rod |  | 30d | 2023-04-30 | 2023-05-29 | 15 | 2021-09-26 | 2021-10-15 | 20d | 2021-10-27 | 2022-04-14 | 0d |  | 102/2/10 | 102/3/8 | 1402/2/10 | 1402/3/8 |
| 17 | 1.3.1.4 | Cylinder |  | 30d | 2023-05-30 | 2023-06-28 | 16 | 2021-09-26 | 2021-10-15 | 20d | 2021-10-27 | 2022-04-14 | 0d |  | 102/3/9 | 102/4/7 | 1402/3/9 | 1402/4/7 |
| 18 | 1.3.1.5 | Piston Rod |  | 30d | 2023-06-29 | 2023-07-28 | 17 |  |  |  |  |  | 0d |  | 102/4/8 | 102/5/6 | 1402/4/8 | 1402/5/6 |
| 19 | 1.3.1.6 | Piston Body |  | 30d | 2023-07-29 | 2023-08-27 | 18 | 2021-10-06 | 2021-10-25 | 20d | 2021-11-06 | 2022-02-03 | 0d |  | 102/5/7 | 102/6/5 | 1402/5/7 | 1402/6/5 |
| 20 | 1.3.1.7 | Ring & Packing |  | 30d | 2023-08-28 | 2023-09-26 | 19 | 2021-10-06 | 2021-10-25 | 20d | 2021-11-06 | 2022-02-03 | 0d |  | 102/6/6 | 102/7/4 | 1402/6/6 | 1402/7/4 |
| 21 | 1.3.1.8 | Cylinder Valve |  | 30d | 2023-09-27 | 2023-10-26 | 20 |  |  |  |  |  | 0d |  | 102/7/5 | 102/8/4 | 1402/7/5 | 1402/8/4 |
| 22 | 1.3.1.9 | Coupling |  | 30d | 2023-10-27 | 2023-11-25 | 21 | 2021-10-16 | 2021-11-04 | 20d | 2021-11-16 | 2022-03-25 | 0d |  | 102/8/5 | 102/9/4 | 1402/8/5 | 1402/9/4 |
| 23 | 1.3.1.10 | Bolt & Gasket |  | 30d | 2023-11-26 | 2023-12-25 | 22 | 2021-10-16 | 2021-11-04 | 20d | 2021-11-16 | 2022-03-25 | 0d |  | 102/9/5 | 102/10/4 | 1402/9/5 | 1402/10/4 |
| 24 | 1.3.1.11 | Accessory |  | 30d | 2023-12-26 | 2024-01-24 | 23 |  |  |  |  |  | 0d |  | 102/10/5 | 102/11/4 | 1402/10/5 | 1402/11/4 |

| ID | WBS | Task | Duration | Start | Finish | Predecessors | Baseline start | Baseline finish | Baseline duration | Baseline 1 start | Baseline 1 finish | Total slack | Free slack | Start Date | Finish Date | شروع | پایان |
| --- | --- | --- | --- | --- | --- | --- | --- | --- | --- | --- | --- | --- | --- | --- | --- | --- | --- |
| 25 | 1.3.2 | **Main Motors** | 240d | 2023-05-03 | 2023-12-28 |  | 2022-02-13 | 2022-04-03 | 50d | 2022-02-24 | 2022-04-14 | 27d |  | 101/11/8 | 102/10/7 | 1402/2/13 | 1402/10/7 |
| 26 | 1.3.2.1 | Raw Material | 80d | 2023-05-03 | 2023-07-21 | 15FS+3d |  |  |  |  |  | 27d | 0d | 102/2/13 | 102/4/30 | 1402/2/13 | 1402/4/30 |
| 27 | 1.3.2.2 | Fabrication | 155d | 2023-07-22 | 2023-12-23 | 26 |  |  |  |  |  | 27d | 0d | 102/4/31 | 102/10/2 | 1402/4/31 | 1402/10/2 |
| 28 | 1.3.2.3 | Inspection | 5d | 2023-12-24 | 2023-12-28 | 27 |  |  |  |  |  | 27d |  | 102/10/3 | 102/10/7 | 1402/10/3 | 1402/10/7 |
| 29 | 1.3.3 | **Lube Oil System** | 180d | 2023-03-31 | 2023-09-26 |  | 2022-02-13 | 2022-04-03 | 50d | 2022-02-24 | 2022-04-14 | 0d |  | 101/11/8 | 102/7/4 | 1402/1/11 | 1402/7/4 |
| 30 | 1.3.3.1 | Raw Material | 85d | 2023-03-31 | 2023-06-23 | 15SS |  |  |  |  |  | 0d |  | 102/1/11 | 102/4/2 | 1402/1/11 | 1402/4/2 |
| 31 | 1.3.3.2 | Fabrication | 90d | 2023-06-24 | 2023-09-21 | 30 |  |  |  |  |  | 0d |  | 102/4/3 | 102/6/30 | 1402/4/3 | 1402/6/30 |
| 32 | 1.3.3.3 | Inspection | 5d | 2023-09-22 | 2023-09-26 | 31 |  |  |  |  |  | 0d |  | 102/6/31 | 102/7/4 | 1402/6/31 | 1402/7/4 |
| 33 | 1.3.4 | **Water Jacket Skid** | 210d | 2023-05-02 | 2023-11-27 |  |  |  |  |  |  | 58d |  | 101/11/9 | 102/9/6 | 1402/2/12 | 1402/9/6 |
| 34 | 1.3.4.1 | Raw Material | 90d | 2023-05-02 | 2023-07-30 | 15SS+32d |  |  |  |  |  | 58d | 0d | 102/2/12 | 102/5/8 | 1402/2/12 | 1402/5/8 |
| 35 | 1.3.4.2 | Fabrication | 115d | 2023-07-31 | 2023-11-22 | 34 |  |  |  |  |  | 58d | 0d | 102/5/9 | 102/9/1 | 1402/5/9 | 1402/9/1 |
| 36 | 1.3.4.3 | Inspection | 5d | 2023-11-23 | 2023-11-27 | 35 |  |  |  |  |  | 58d |  | 102/9/2 | 102/9/6 | 1402/9/2 | 1402/9/6 |
| 37 | 1.3.5 | **Snubber** | 85d | 2023-09-27 | 2023-12-20 |  | 2022-02-13 | 2022-04-03 | 50d | 2022-02-24 | 2022-04-14 | 0d |  | 101/11/8 | 102/9/29 | 1402/7/5 | 1402/9/29 |
| 38 | 1.3.5.1 | Raw Material | 30d | 2023-09-27 | 2023-10-26 | 32 |  |  |  |  |  | 0d |  | 102/7/5 | 102/8/4 | 1402/7/5 | 1402/8/4 |
| 39 | 1.3.5.2 | Fabrication | 50d | 2023-10-27 | 2023-12-15 | 38 |  |  |  |  |  | 35d | 0d | 102/8/5 | 102/9/24 | 1402/8/5 | 1402/9/24 |
| 40 | 1.3.5.3 | Inspection | 5d | 2023-12-16 | 2023-12-20 | 39 |  |  |  |  |  | 35d |  | 102/9/25 | 102/9/29 | 1402/9/25 | 1402/9/29 |
| 41 | 1.3.6 | **Instrument** | 85d | 2023-09-27 | 2023-12-20 |  | 2022-02-13 | 2022-04-03 | 50d | 2022-02-24 | 2022-04-14 | 0d |  | 101/11/8 | 102/9/29 | 1402/7/5 | 1402/9/29 |
| 42 | 1.3.6.1 | Raw Material | 30d | 2023-09-27 | 2023-10-26 | 38SS |  |  |  |  |  | 0d |  | 102/7/5 | 102/8/4 | 1402/7/5 | 1402/8/4 |
| 43 | 1.3.6.2 | Fabrication | 50d | 2023-10-27 | 2023-12-15 | 42 |  |  |  |  |  | 35d | 0d | 102/8/5 | 102/9/24 | 1402/8/5 | 1402/9/24 |
| 44 | 1.3.6.3 | Inspection | 5d | 2023-12-16 | 2023-12-20 | 43 |  |  |  |  |  | 35d |  | 102/9/25 | 102/9/29 | 1402/9/25 | 1402/9/29 |
| 45 | 1.3.7 | **UCP** | 90d | 2023-08-04 | 2023-11-01 |  |  |  |  |  |  | 84d |  | 101/11/9 | 102/8/10 | 1402/5/13 | 1402/8/10 |
| 46 | 1.3.7.1 | Raw Material | 30d | 2023-08-04 | 2023-09-02 | 27SS+13d |  |  |  |  |  | 84d | 0d | 102/5/13 | 102/6/11 | 1402/5/13 | 1402/6/11 |
| 47 | 1.3.7.2 | Fabrication | 55d | 2023-09-03 | 2023-10-27 | 46 |  |  |  |  |  | 84d | 0d | 102/6/12 | 102/8/5 | 1402/6/12 | 1402/8/5 |
| 48 | 1.3.7.3 | Inspection | 5d | 2023-10-28 | 2023-11-01 | 47 |  |  |  |  |  | 84d |  | 102/8/6 | 102/8/10 | 1402/8/6 | 1402/8/10 |

| ID | WBS | Task | Duration | Start | Finish | Predecessors | Baseline start | Baseline finish | Baseline duration | Baseline 1 start | Baseline 1 finish | Total slack | Free slack | Start Date | Finish Date | شروع | پایان |
| --- | --- | --- | --- | --- | --- | --- | --- | --- | --- | --- | --- | --- | --- | --- | --- | --- | --- |
| 49 | 1.3.8 | **Main Control Valves** | 90d | 2023-09-27 | 2023-12-25 |  |  |  |  |  |  | 30d |  | 101/11/8 | 102/10/4 | 1402/7/5 | 1402/10/4 |
| 50 | 1.3.8.1 | Raw Material | 30d | 2023-09-27 | 2023-10-26 | 42SS |  |  |  |  |  | 30d | 0d | 102/7/5 | 102/8/4 | 1402/7/5 | 1402/8/4 |
| 51 | 1.3.8.2 | Fabrication | 55d | 2023-10-27 | 2023-12-20 | 50 |  |  |  |  |  | 30d | 0d | 102/8/5 | 102/9/29 | 1402/8/5 | 1402/9/29 |
| 52 | 1.3.8.3 | Inspection | 5d | 2023-12-21 | 2023-12-25 | 51 |  |  |  |  |  | 30d |  | 102/9/30 | 102/10/4 | 1402/9/30 | 1402/10/4 |
| 53 | 1.3.9 | **Manual Valves** | 30d | 2023-09-27 | 2023-10-26 |  |  |  |  |  |  | 90d |  | 101/11/8 | 102/8/4 | 1402/7/5 | 1402/8/4 |
| 54 | 1.3.9.1 | Raw Material | 25d | 2023-09-27 | 2023-10-21 | 50SS |  |  |  |  |  | 90d | 0d | 102/7/5 | 102/7/29 | 1402/7/5 | 1402/7/29 |
| 55 | 1.3.9.2 | Fabrication | 4d | 2023-10-22 | 2023-10-25 | 54 |  |  |  |  |  | 90d | 0d | 102/7/30 | 102/8/3 | 1402/7/30 | 1402/8/3 |
| 56 | 1.3.9.3 | Inspection | 1d | 2023-10-26 | 2023-10-26 | 55 |  |  |  |  |  | 90d |  | 102/8/4 | 102/8/4 | 1402/8/4 | 1402/8/4 |
| 57 | 1.3.10 | **Piping Material** | 90d | 2023-09-27 | 2023-12-25 |  |  |  |  |  |  | 30d |  | 101/11/9 | 102/10/4 | 1402/7/5 | 1402/10/4 |
| 58 | 1.3.10.1 | Raw Material | 40d | 2023-09-27 | 2023-11-05 | 21SS |  |  |  |  |  | 30d | 0d | 102/7/5 | 102/8/14 | 1402/7/5 | 1402/8/14 |
| 59 | 1.3.10.2 | Fabrication | 47d | 2023-11-06 | 2023-12-22 | 58 |  |  |  |  |  | 30d | 0d | 102/8/15 | 102/10/1 | 1402/8/15 | 1402/10/1 |
| 60 | 1.3.10.3 | Inspection | 3d | 2023-12-23 | 2023-12-25 | 59 |  |  |  |  |  | 30d |  | 102/10/2 | 102/10/4 | 1402/10/2 | 1402/10/4 |
| 61 | 1.3.11 | **Collection Pot** | 90d | 2023-09-27 | 2023-12-25 |  | 2022-02-13 | 2022-04-03 | 50d | 2022-02-24 | 2022-04-14 | 30d |  | 101/11/8 | 102/10/4 | 1402/7/5 | 1402/10/4 |
| 62 | 1.3.11.1 | Raw Material | 30d | 2023-09-27 | 2023-10-26 | 78SS |  |  |  |  |  | 30d | 0d | 102/7/5 | 102/8/4 | 1402/7/5 | 1402/8/4 |
| 63 | 1.3.11.2 | Fabrication | 55d | 2023-10-27 | 2023-12-20 | 62 |  |  |  |  |  | 30d | 0d | 102/8/5 | 102/9/29 | 1402/8/5 | 1402/9/29 |
| 64 | 1.3.11.3 | Inspection | 5d | 2023-12-21 | 2023-12-25 | 63 |  |  |  |  |  | 30d |  | 102/9/30 | 102/10/4 | 1402/9/30 | 1402/10/4 |
| 65 | 1.3.12 | **Main Skid** | 90d | 2023-10-27 | 2024-01-24 |  | 2022-02-13 | 2022-04-03 | 50d | 2022-02-24 | 2022-04-14 | 0d |  | 101/11/8 | 102/11/4 | 1402/8/5 | 1402/11/4 |
| 66 | 1.3.12.1 | Raw Material | 30d | 2023-10-27 | 2023-11-25 | 42 |  |  |  |  |  | 0d |  | 102/8/5 | 102/9/4 | 1402/8/5 | 1402/9/4 |
| 67 | 1.3.12.2 | Fabrication | 59d | 2023-11-26 | 2024-01-23 | 66 |  |  |  |  |  | 0d |  | 102/9/5 | 102/11/3 | 1402/9/5 | 1402/11/3 |
| 68 | 1.3.12.3 | Inspection | 1d | 2024-01-24 | 2024-01-24 | 67 |  |  |  |  |  | 0d |  | 102/11/4 | 102/11/4 | 1402/11/4 | 1402/11/4 |
| 69 | 1.3.13 | **Strainer** | 90d | 2023-09-27 | 2023-12-25 |  |  |  |  |  |  | 30d |  | 101/11/8 | 102/10/4 | 1402/7/5 | 1402/10/4 |
| 70 | 1.3.13.1 | Raw Material | 35d | 2023-09-27 | 2023-10-31 | 50SS |  |  |  |  |  | 30d | 0d | 102/7/5 | 102/8/9 | 1402/7/5 | 1402/8/9 |
| 71 | 1.3.13.2 | Fabrication | 50d | 2023-11-01 | 2023-12-20 | 70 |  |  |  |  |  | 30d | 0d | 102/8/10 | 102/9/29 | 1402/8/10 | 1402/9/29 |
| 72 | 1.3.13.3 | Inspection | 5d | 2023-12-21 | 2023-12-25 | 71 |  |  |  |  |  | 30d |  | 102/9/30 | 102/10/4 | 1402/9/30 | 1402/10/4 |

| ID | WBS | Task | Duration | Start | Finish | Predecessors | Total slack | Free slack | Start Date | Finish Date | شروع | پایان |
| --- | --- | --- | --- | --- | --- | --- | --- | --- | --- | --- | --- | --- |
| 73 | 1.3.14 | **TSV-PSV** | 90d | 2023-09-27 | 2023-12-25 |  | 30d |  | 101/11/8 | 102/10/4 | 1402/7/5 | 1402/10/4 |
| 74 | 1.3.14.1 | Raw Material | 30d | 2023-09-27 | 2023-10-26 | 70SS | 30d | 0d | 102/7/5 | 102/8/4 | 1402/7/5 | 1402/8/4 |
| 75 | 1.3.14.2 | Fabrication | 55d | 2023-10-27 | 2023-12-20 | 74 | 30d | 0d | 102/8/5 | 102/9/29 | 1402/8/5 | 1402/9/29 |
| 76 | 1.3.14.3 | Inspection | 5d | 2023-12-21 | 2023-12-25 | 75 | 30d |  | 102/9/30 | 102/10/4 | 1402/9/30 | 1402/10/4 |
| 77 | 1.3.15 | **LCP** | 90d | 2023-09-27 | 2023-12-25 |  | 10d |  | 101/11/8 | 102/10/4 | 1402/7/5 | 1402/10/4 |
| 78 | 1.3.15.1 | Raw Material | 40d | 2023-09-27 | 2023-11-05 | 21SS | 10d | 0d | 102/7/5 | 102/8/14 | 1402/7/5 | 1402/8/14 |
| 79 | 1.3.15.2 | Fabrication | 45d | 2023-11-06 | 2023-12-20 | 78 | 30d | 0d | 102/8/15 | 102/9/29 | 1402/8/15 | 1402/9/29 |
| 80 | 1.3.15.3 | Inspection | 5d | 2023-12-21 | 2023-12-25 | 79 | 30d |  | 102/9/30 | 102/10/4 | 1402/9/30 | 1402/10/4 |
| 81 | 1.3.16 | **Gauge Board** | 30d | 2023-11-06 | 2023-12-05 |  | 10d |  | 101/11/8 | 102/9/14 | 1402/8/15 | 1402/9/14 |
| 82 | 1.3.16.1 | Raw Material | 25d | 2023-11-06 | 2023-11-30 | 78 | 10d | 0d | 102/8/15 | 102/9/9 | 1402/8/15 | 1402/9/9 |
| 83 | 1.3.16.2 | Fabrication | 4d | 2023-12-01 | 2023-12-04 | 82 | 50d | 0d | 102/9/10 | 102/9/13 | 1402/9/10 | 1402/9/13 |
| 84 | 1.3.16.3 | Inspection | 1d | 2023-12-05 | 2023-12-05 | 83 | 50d |  | 102/9/14 | 102/9/14 | 1402/9/14 | 1402/9/14 |
| 85 | 1.3.17 | **Cable** | 25d | 2023-12-01 | 2023-12-25 |  | 10d |  | 101/11/8 | 102/10/4 | 1402/9/10 | 1402/10/4 |
| 86 | 1.3.17.1 | Raw Material | 20d | 2023-12-01 | 2023-12-20 | 82 | 10d | 0d | 102/9/10 | 102/9/29 | 1402/9/10 | 1402/9/29 |
| 87 | 1.3.17.2 | Fabrication | 4d | 2023-12-21 | 2023-12-24 | 86 | 30d | 0d | 102/9/30 | 102/10/3 | 1402/9/30 | 1402/10/3 |
| 88 | 1.3.17.3 | Inspection | 1d | 2023-12-25 | 2023-12-25 | 87 | 30d |  | 102/10/4 | 102/10/4 | 1402/10/4 | 1402/10/4 |
| 89 | 1.3.18 | **Cable Tray** | 25d | 2023-12-21 | 2024-01-14 |  | 10d |  | 101/11/8 | 102/10/24 | 1402/9/30 | 1402/10/24 |
| 90 | 1.3.18.1 | Raw Material | 10d | 2023-12-21 | 2023-12-30 | 86 | 10d | 0d | 102/9/30 | 102/10/9 | 1402/9/30 | 1402/10/9 |
| 91 | 1.3.18.2 | Fabrication | 14d | 2023-12-31 | 2024-01-13 | 90 | 10d | 0d | 102/10/10 | 102/10/23 | 1402/10/10 | 1402/10/23 |
| 92 | 1.3.18.3 | Inspection | 1d | 2024-01-14 | 2024-01-14 | 91 | 10d |  | 102/10/24 | 102/10/24 | 1402/10/24 | 1402/10/24 |
| 93 | 1.4 | **Fabrication** | 58d | 2024-01-25 | 2024-03-22 |  | 0d |  | 101/11/8 | 103/1/3 | 1402/11/5 | 1403/1/3 |
| 94 | 1.4.1 | **Compressor Package Assembly** | 58d | 2024-01-25 | 2024-03-22 |  | 0d |  | 101/11/8 | 103/1/3 | 1402/11/5 | 1403/1/3 |
| 95 | 1.4.1.1 | Package Assembly | 48d | 2024-01-25 | 2024-03-12 | 24, 28, 32, 36, 40, 44, 48, 52, 56, 60, 64, 68, 72, 76, 80, 84, 88, 92 | 0d |  | 102/11/5 | 102/12/22 | 1402/11/5 | 1402/12/22 |
| 96 | 1.4.1.2 | Final Inspection | 4d | 2024-03-13 | 2024-03-16 | 95 | 0d |  | 102/12/23 | 102/12/26 | 1402/12/23 | 1402/12/26 |
| 97 | 1.4.1.3 | Final Book | 4d | 2024-03-17 | 2024-03-20 | 96 | 0d |  | 102/12/27 | 103/1/1 | 1402/12/27 | 1403/1/1 |
| 98 | 1.4.1.4 | EX Work | 2d | 2024-03-21 | 2024-03-22 | 97 | 0d |  | 103/1/2 | 103/1/3 | 1403/1/2 | 1403/1/3 |

| ID | WBS | Task | Duration | Start | Finish | Predecessors | Baseline start | Baseline finish | Baseline duration | Baseline 1 start | Baseline 1 finish | Total slack | Start Date | Finish Date | شروع | پایان |
| --- | --- | --- | --- | --- | --- | --- | --- | --- | --- | --- | --- | --- | --- | --- | --- | --- |
| 99 | 1.5 | **SAT & Performance Test** | 120d | 2024-04-22 | 2024-08-19 |  | 2022-02-03 | 2022-04-08 | 65d | 2022-03-06 | 2022-05-26 | 0d | 101/9/8 | 103/5/29 | 1403/2/3 | 1403/5/29 |
| 100 | 1.5.1 | Equipment Installation | 90d | 2024-04-22 | 2024-07-20 | 98FS+30d | 2022-04-04 | 2022-04-08 | 5d | 2022-05-22 | 2022-05-26 | 0d | 103/2/3 | 103/4/30 | 1403/2/3 | 1403/4/30 |
| 101 | 1.5.2 | SAT & Performance Test activities | 30d | 2024-07-21 | 2024-08-19 | 100 | 2022-02-03 | 2022-02-09 | 7d | 2022-03-06 | 2022-03-12 | 0d | 103/4/31 | 103/5/29 | 1403/4/31 | 1403/5/29 |
